# Proyecto Montaje Entrega final_1.1

Schedule from MS Project, 2021-01-02 to 2022-12-29, status date 2021-06-09, costs in $, A marks actual dates.

## Calendars

- CAlendario proyecto: Mon-Sat 08:00-12:00, 14:00-18:00; Sun off. Exceptions (off unless hours are given): 2021-01-02.

## Resources

| Resource | Unit | Rate |
| --- | --- | --- |
| Director de Proyecto |  | 32615 |
| Coordinador de montaje |  | 26092 |
| Coordinador de compras |  | 22830 |
| Almacenista 1 |  | 9458 |
| Mecánico de montaje 1 |  | 18264 |
| Auxiliar de montaje 1 |  | 10437 |
| Soldador 1 |  | 9915 |
| Supervisor mecánico 1 |  | 11741 |
| Tubero 1 |  | 9458 |
| Ingeniero de instrumentación y control |  | 24787 |
| Ingeniero electricista |  | 24787 |
| Electricista 1 |  | 13046 |
| Ayudante de electricista 1 |  | 9328 |
| Operador de grúa |  | 11741 |
| Ayudante de operador de grúa |  | 7828 |
| Dibujante de ingeniería 1 |  | 10176 |
| Operador de montacarga 1 |  | 11741 |
| Ingeniero de alineación y medición de vibraciones |  | 22830 |
| Ingeniero civil |  | 22830 |
| Oficial |  | 9458 |
| Profesional de Seguridad y Salud en el Trabajo 1 |  | 13046 |
| Jefe de producción |  | 20873 |
| Jefe de mantenimiento |  | 19569 |
| Coordinador de producción |  | 20873 |
| Auxiliar de producción 1 |  | 11089 |
| Operarios de producción 1 |  | 10437 |
| Almacenista 2 |  | 9458 |
| Mecánico de montaje 7 |  | 18264 |
| Mecánico de montaje 6 |  | 18264 |
| Mecánico de montaje 5 |  | 18264 |
| Mecánico de montaje 4 |  | 18264 |
| Mecánico de montaje 3 |  | 18264 |
| Mecánico de montaje 2 |  | 18264 |
| Mecánico de montaje 8 |  | 18264 |
| Mecánico de montaje 9 |  | 18264 |
| Mecánico de montaje 10 |  | 18264 |
| Auxiliar de montaje 7 |  | 10437 |
| Auxiliar de montaje 6 |  | 10437 |
| Auxiliar de montaje 5 |  | 10437 |
| Auxiliar de montaje 4 |  | 10437 |
| Auxiliar de montaje 3 |  | 10437 |
| Auxiliar de montaje 2 |  | 10437 |
| Auxiliar de montaje 8 |  | 10437 |
| Auxiliar de montaje 9 |  | 10437 |
| Auxiliar de montaje 10 |  | 10437 |
| Soldador 5 |  | 9915 |
| Soldador 2 |  | 9915 |
| Soldador 3 |  | 9915 |
| Soldador 4 |  | 9915 |
| Supervisor mecánico 2 |  | 11741 |
| Tubero 4 |  | 9458 |
| Tubero 3 |  | 9458 |
| Tubero 2 |  | 9458 |
| Tubero 5 |  | 9458 |
| Electricista 7 |  | 13046 |
| Electricista 6 |  | 13046 |
| Electricista 2 |  | 13046 |
| Electricista 3 |  | 13046 |
| Electricista 4 |  | 13046 |
| Electricista 5 |  | 13046 |
| Electricista 8 |  | 13046 |
| Electricista 9 |  | 13046 |
| Electricista 10 |  | 13046 |
| Ayudante de electricista 6 |  | 9328 |
| Ayudante de electricista 5 |  | 9328 |
| Ayudante de electricista 2 |  | 9328 |
| Ayudante de electricista 3 |  | 9328 |
| Ayudante de electricista 4 |  | 9328 |
| Ayudante de electricista 7 |  | 9328 |
| Ayudante de electricista 8 |  | 9328 |
| Ayudante de electricista 9 |  | 9328 |
| Ayudante de electricista 10 |  | 9328 |
| Dibujante de ingeniería 2 |  | 10176 |
| Operador de montacarga 4 |  | 11741 |
| Operador de montacarga 3 |  | 11741 |
| Operador de montacarga 2 |  | 11741 |
| Profesional de Seguridad y Salud en el Trabajo 2 |  | 13046 |
| Auxiliar de producción 2 |  | 11089 |
| Operarios de producción 2 |  | 10437 |
| Operarios de producción 3 |  | 10437 |
| Soldadura | Kg | 12900 |
| Disco de corte | x Unid | 6200 |
| Tornillería varia | x Unid | 4500000 |
| Acetileno por 4Kg | x Unid | 400000 |
| Oxigeno | x Unid | 1895000 |
| Cemento por 50 Kg | x Unid | 26200 |
| Brocas | x Unid | 5630 |
| Endurecedor | x Unid | 32430 |
| Silicona | x Unid | 9700 |
| Pintura | Cuñete | 75000 |
| Anticorrosivo | Cuñete | 56000 |
| Equipo de protección contra caidas | x Unid | 545000 |
| Elevador de personas | x Unid | 4500000 |
| Diferenciales | x Unid | 2340000 |
| Herramienta menor |  | 3500000 |
| Banda alimentación de botellas. |  | 150000000 |
| Abridor de pacas. |  | 500000000 |
| Banda de transporte. |  | 20000000 |
| Banda de alimentación a equipo pre lavado. |  | 80000000 |
| Equipo pre lavado rotativo. |  | 600000000 |
| Equipo separador de etiquetas 3 módulos. |  | 900000000 |
| Banda de transporte con detector de metal 1 |  | 60000000 |
| Banda de transporte con detector de metal 2 |  | 60000000 |
| Banda de transporte con detector de metal 3 |  | 60000000 |
| Banda de selección manual |  | 60000000 |
| Banda de alimentación de los molinos |  | 30000000 |
| Molino de corte 1 |  | 1200000000 |
| Molino de corte 2 |  | 1200000000 |
| Ventiladores de transporte con tubería |  | 40000000 |
| Reactor de lavado 1, 2, 3. |  | 600000000 |
| Sistema de recirculación de agua de los molinos |  | 30000000 |
| Tanque de flotación |  | 120000000 |
| Hilos de almacenamiento 1,2,3 |  | 1200000000 |
| Empacadora neumática |  | 200000000 |
| Extrusor de doble tornillo |  | 4000000000 |
| Cortadora |  | 200000000 |
| Empacadora de granulo |  | 150000000 |
| Computador Portatil | x Unid | 1800000 |
| Impresora/ploter | x Unid | 350000 |
| Papeleria | Paquete | 333333 |
| Servicio internet | x Unid | 75000 |
| Celular comunicación | x Unid | 250000 |
| servicio comunicación | x Unid | 25000 |
| Software | x Unid | 1000000 |
| Alquiler de Montacarga | x Unid | 89000 |
| Profesio... |  |  |
| Pintur... |  |  |
| Ingeniero... |  |  |

## Schedule

| ID | WBS | Task | Duration | Start | Finish | Predecessors | Complete | Remaining | Baseline start | Baseline finish | Baseline duration | Baseline 1 start | Baseline 1 finish | Total slack | Resources | Work | Actual work | Cost | Baseline cost | Actual cost |
| --- | --- | --- | --- | --- | --- | --- | --- | --- | --- | --- | --- | --- | --- | --- | --- | --- | --- | --- | --- | --- |
| 1 | 1 | **Montaje de planta de reciclaje de material PET** | 621.25d | 2021-01-02 A | 2022-12-29 |  | 31% | 430.4d | 2021-01-02 | 2022-12-29 | 621.25d | 2021-01-02 | 2022-12-29 | 0d |  | 264334h | 15305.5h | 30,572,526,450.29 | 15,243,245,251 | 3,604,868,803.66 |
| 2 | 1.1 | **1.1 INGENIERÍA Y DISEÑO** | 149d | 2021-01-02 A | 2021-06-24 |  | 95% | 6.77d | 2021-01-02 | 2021-06-24 | 125d | 2021-01-02 | 2021-06-24 |  |  | 9715h | 9255.4h | 34,575,525.63 | 26,598,336 | 21,998,435.3 |
| 3 | 1.1.1 | **1.1.1 Calculo de equipos** | 148d | 2021-01-02 A | 2021-06-24 |  | 90% | 14.8d | 2021-01-02 | 2021-06-24 | 148d | 2021-01-02 | 2021-06-24 | 473.25d |  | 4191h | 3731.4h | 21,259,435.63 | 9,518,423 | 8,682,345.3 |
| 4 | 1.1.1.1 | 1.1.1.1 Realizar comités programados de ingeniería de proyectos. | 143.62d | 2021-01-02 A | 2021-06-24 |  | 90% | 14.36d | 2021-01-02 | 2021-06-24 | 143.62d | 2021-01-02 | 2021-06-24 | 473.25d | Coordinador de montaje; Dibujante de ingeniería 1; Director de Proyecto; Ingeniero de instrumentación y control; Computador Portatil [2 x Unid]; Software [1 x Unid]; Celular comunicación [1 x Unid]; Impresora/ploter [1 x Unid]; Papeleria [1 Paquete]; Servicio internet [1 x Unid] | 4191h | 3731.4h | 21,259,435.63 | 9,518,423 | 8,682,345.3 |
| 5 | 1.1.2 | **1.1.2 Selección de equipos** | 71d | 2021-02-05 A | 2021-04-28 A |  | 100% |  | 2021-02-05 | 2021-04-28 | 71d | 2021-02-05 | 2021-04-28 |  |  | 2260h | 2260h | 1,000,000 | 4,763,823 | 1,000,000 |
| 6 | 1.1.2.1 | 1.1.2.1 Realizar análisis de oferta de proveedores | 55.62d | 2021-02-05 A | 2021-04-13 A | 4 | 100% |  | 2021-02-05 | 2021-04-13 | 55.62d | 2021-02-05 | 2021-04-13 |  | Coordinador de montaje; Dibujante de ingeniería 1; Director de Proyecto; Ingeniero de instrumentación y control; Computador Portatil [2 x Unid]; Software [1 x Unid]; Celular comunicación [1 x Unid]; Impresora/ploter [1 x Unid]; Papeleria [1 Paquete] | 1780h | 1780h |  |  |  |
| 7 | 1.1.2.2 | 1.1.2.2 Aprobar oferta de proveedores por Presidencia | 15d | 2021-02-05 A | 2021-04-28 A | 6 | 100% |  | 2021-02-05 | 2021-04-28 | 15d | 2021-02-05 | 2021-04-28 |  | Coordinador de montaje; Dibujante de ingeniería 1; Director de Proyecto; Ingeniero de instrumentación y control; Computador Portatil [2 x Unid]; Software [1 x Unid]; Celular comunicación [1 x Unid]; Impresora/ploter [1 x Unid]; Papeleria [1 Paquete] | 480h | 480h | 1,000,000 | 4,763,823 | 1,000,000 |
| 8 | 1.1.3 | **1.1.3 Diseño de Planta, planos PID & Layout** | 40.88d | 2021-03-05 A | 2021-04-21 A |  | 100% |  | 2021-03-05 | 2021-04-21 | 40.88d | 2021-03-05 | 2021-04-21 |  |  | 1504h | 1504h | 8,028,734 | 8,028,734 | 8,028,734 |
| 9 | 1.1.3.1 | 1.1.3.1 Diseñar y presentar diferentes propuestas de Layout. | 31d | 2021-03-05 A | 2021-04-13 A | 7 | 100% |  | 2021-03-05 | 2021-04-13 | 31d | 2021-03-05 | 2021-04-13 |  | Coordinador de montaje; Dibujante de ingeniería 1; Director de Proyecto; Ingeniero de instrumentación y control; Computador Portatil [2 x Unid]; Software [1 x Unid]; Celular comunicación [1 x Unid]; Impresora/ploter [1 x Unid]; Papeleria [1 Paquete] | 992h | 992h |  |  |  |
| 10 | 1.1.3.2 | 1.1.3.4 Aprobar propuesta por comité de ingeniería | 16d | 2021-04-03 A | 2021-04-21 A | 9 | 100% |  | 2021-04-03 | 2021-04-21 | 16d | 2021-04-03 | 2021-04-21 |  | Coordinador de montaje; Dibujante de ingeniería 1; Director de Proyecto; Ingeniero de instrumentación y control; Computador Portatil [2 x Unid]; Software [1 x Unid]; Celular comunicación [1 x Unid]; Impresora/ploter [1 x Unid]; Papeleria [1 Paquete] | 512h | 512h | 8,028,734 | 8,028,734 | 8,028,734 |
| 11 | 1.1.4 | **1.1.4 Cronograma de montaje** | 30.75d | 2021-04-05 A | 2021-05-10 A |  | 100% |  | 2021-04-05 | 2021-05-10 | 30.75d | 2021-04-05 | 2021-05-10 |  |  | 992h | 992h | 2,093,452 | 2,093,452 | 2,093,452 |
| 12 | 1.1.4.1 | 1.1.4.1 Presupuestar tiempo de montaje de acuerdo al Layout definido en comité de Ingeniería | 31d | 2021-04-05 A | 2021-05-10 A | 10 | 100% |  | 2021-04-05 | 2021-05-10 | 31d | 2021-04-05 | 2021-05-10 |  | Coordinador de montaje; Dibujante de ingeniería 1; Director de Proyecto; Ingeniero de instrumentación y control; Computador Portatil [2 x Unid]; Software [1 x Unid]; Celular comunicación [1 x Unid]; Impresora/ploter [1 x Unid]; Papeleria [1 Paquete] | 992h | 992h | 2,093,452 | 2,093,452 | 2,093,452 |
| 13 | 1.1.5 | **1.1.5 Selección de proveedores varios** | 15.38d | 2021-04-05 A | 2021-04-22 A |  | 100% |  | 2021-04-05 | 2021-04-22 | 15.38d | 2021-04-05 | 2021-04-22 |  |  | 512h | 512h | 1,306,741 | 1,306,741 | 1,306,741 |
| 14 | 1.1.5.1 | 1.1.5.1 Determinar qué tipo de mano de obra, servicios y materiales se requiere para el montaje | 16d | 2021-04-05 A | 2021-04-22 A | 12 | 100% |  | 2021-04-05 | 2021-04-22 | 16d | 2021-04-05 | 2021-04-22 |  | Coordinador de montaje; Dibujante de ingeniería 1; Director de Proyecto; Ingeniero de instrumentación y control; Computador Portatil [2 x Unid]; Software [1 x Unid]; Celular comunicación [1 x Unid]; Impresora/ploter [1 x Unid]; Papeleria [1 Paquete] | 512h | 512h | 1,306,741 | 1,306,741 | 1,306,741 |
| 15 | 1.1.6 | **1.1.6 Selección de Personal de montaje** | 7.62d | 2021-04-05 A | 2021-04-13 A |  | 100% |  | 2021-04-05 | 2021-04-13 | 7.62d | 2021-04-05 | 2021-04-13 |  |  | 256h | 256h | 887,163 | 887,163 | 887,163 |
| 16 | 1.1.6.1 | 1.1.6.1 Determinar qué tipo de mano de obra especializada se requiere. | 8d | 2021-04-05 A | 2021-04-13 A | 14 | 100% |  | 2021-04-05 | 2021-04-13 | 8d | 2021-04-05 | 2021-04-13 |  | Coordinador de montaje; Dibujante de ingeniería 1; Director de Proyecto; Ingeniero de instrumentación y control; Computador Portatil [2 x Unid]; Software [1 x Unid]; Celular comunicación [1 x Unid]; Impresora/ploter [1 x Unid]; Papeleria [1 Paquete] | 256h | 256h | 887,163 | 887,163 | 887,163 |
| 17 | 1.2 | **1.2 COTIZACIÓN Y SELECCIÓN DE PROVEEDORES** | 41.38d | 2021-04-12 A | 2021-05-29 A |  | 100% |  | 2021-04-12 | 2021-05-29 | 41.38d | 2021-04-12 | 2021-05-29 |  |  | 1896h | 1896h | 5,069,933 | 5,069,933 | 5,069,933 |
| 18 | 1.2.1 | **1.2.1 Negociación de cotizaciones** | 15.38d | 2021-04-13 A | 2021-04-30 A |  | 100% |  | 2021-04-13 | 2021-04-30 | 15.38d | 2021-04-13 | 2021-04-30 |  |  | 384h | 384h | 867,612 | 867,612 | 867,612 |
| 19 | 1.2.1.1 | 1.2.1.1 Revisar cotizaciones ofertadas de mano de obra y ajustarlas con ofertantes. | 16d | 2021-04-13 A | 2021-04-30 A | 16 | 100% |  | 2021-04-13 | 2021-04-30 | 16d | 2021-04-13 | 2021-04-30 |  | Director de Proyecto; Coordinador de compras; Ingeniero de instrumentación y control; Computador Portatil [1 x Unid]; Servicio internet [1 x Unid]; Celular comunicación [1 x Unid] | 384h | 384h | 867,612 | 867,612 | 867,612 |
| 20 | 1.2.2 | **1.2.2 Negociación de Equipos** | 31.75d | 2021-04-12 A | 2021-05-18 A |  | 100% |  | 2021-04-12 | 2021-05-18 | 31.75d | 2021-04-12 | 2021-05-18 |  |  | 744h | 744h | 1,541,544 | 1,541,544 | 1,541,544 |
| 21 | 1.2.2.1 | 1.2.2.1 Revisar cotizaciones ofertadas de proveedores de equipos y negociarlas. | 31d | 2021-04-12 A | 2021-05-18 A | 19 | 100% |  | 2021-04-12 | 2021-05-18 | 31d | 2021-04-12 | 2021-05-18 |  | Director de Proyecto; Coordinador de compras; Ingeniero de instrumentación y control; Computador Portatil [1 x Unid]; Servicio internet [1 x Unid]; Celular comunicación [1 x Unid] | 744h | 744h | 1,541,544 | 1,541,544 | 1,541,544 |
| 22 | 1.2.3 | **1.2.3 Selección de ICONTERMS** | 7.62d | 2021-04-12 A | 2021-04-20 A |  | 100% |  | 2021-04-12 | 2021-04-20 | 7.62d | 2021-04-12 | 2021-04-20 |  |  | 192h | 192h | 1,284,984 | 1,284,984 | 1,284,984 |
| 23 | 1.2.3.1 | 1.2.3.1 Definir ICONTERMS en conjunto con proveedores de equipos. | 8d | 2021-04-12 A | 2021-04-20 A | 21 | 100% |  | 2021-04-12 | 2021-04-20 | 8d | 2021-04-12 | 2021-04-20 |  | Director de Proyecto; Coordinador de compras; Ingeniero de instrumentación y control; Computador Portatil [1 x Unid]; Servicio internet [1 x Unid]; Celular comunicación [1 x Unid] | 192h | 192h | 1,284,984 | 1,284,984 | 1,284,984 |
| 24 | 1.2.4 | **1.2.4 Definición de proveedor de equipos y montaje** | 16.38d | 2021-05-11 A | 2021-05-29 A |  | 100% |  | 2021-05-11 | 2021-05-29 | 16.38d | 2021-05-11 | 2021-05-29 |  |  | 384h | 384h | 867,612 | 867,612 | 867,612 |
| 25 | 1.2.4.1 | 1.2.4.1 Seleccionar fabricante que suministrará los equipos y de contratista que realizará el montaje. | 16d | 2021-05-11 A | 2021-05-29 A | 23 | 100% |  | 2021-05-11 | 2021-05-29 | 16d | 2021-05-11 | 2021-05-29 |  | Director de Proyecto; Coordinador de compras; Ingeniero de instrumentación y control; Computador Portatil [1 x Unid]; Servicio internet [1 x Unid]; Celular comunicación [1 x Unid] | 384h | 384h | 867,612 | 867,612 | 867,612 |

| ID | WBS | Task | Duration | Start | Finish | Predecessors | Complete | Remaining | Baseline start | Baseline finish | Baseline duration | Baseline 1 start | Baseline 1 finish | Total slack | Free slack | Constraint | Resources | Work | Actual work | Cost | Baseline cost | Actual cost |
| --- | --- | --- | --- | --- | --- | --- | --- | --- | --- | --- | --- | --- | --- | --- | --- | --- | --- | --- | --- | --- | --- | --- |
| 26 | 1.2.5 | **1.2.5 Selección de agencia de aduanas** | 7.62d | 2021-04-12 A | 2021-04-20 A |  | 100% |  | 2021-04-12 | 2021-04-20 | 7.62d | 2021-04-12 | 2021-04-20 |  |  |  |  | 192h | 192h | 508,181 | 508,181 | 508,181 |
| 27 | 1.2.5.1 | 1.2.5.1 Seleccionar agencia de aduanas encargada de la importación en conjunto con área de comercio exterior | 8d | 2021-04-12 A | 2021-04-20 A | 25 | 100% |  | 2021-04-12 | 2021-04-20 | 8d | 2021-04-12 | 2021-04-20 |  |  |  | Director de Proyecto; Coordinador de compras; Ingeniero de instrumentación y control; Computador Portatil [1 x Unid]; Servicio internet [1 x Unid]; Celular comunicación [1 x Unid] | 192h | 192h | 508,181 | 508,181 | 508,181 |
| 28 | 1.3 | **1.3 COMPRA DE EQUIPOS Y TRANSPORTE** | 522.02d | 2021-04-20 A | 2022-12-20 |  | 26% | 384.76d | 2021-04-20 | 2022-09-21 | 446d | 2021-04-20 | 2022-09-27 | 8.22d |  |  |  | 27193h | 4154.1h | 24,603,980,214.66 | 9,282,676,205 | 1,846,354,274.36 |
| 29 | 1.3.1 | **1.3.1 Compra de Equipos** | 186.38d | 2021-04-20 A | 2021-11-23 |  | 30% | 130.46d | 2021-04-20 | 2021-11-23 | 186.38d | 2021-04-20 | 2021-11-23 | 0d |  |  |  | 4299h | 1289.7h | 24,231,676,678.6 | 9,010,279,942 | 1,800,000,000 |
| 30 | 1.3.1.1 | 1.3.1.1 Realizar facturación y orden de compra de equipos. | 179.12d | 2021-04-20 A | 2021-11-23 | 27 | 30% | 125.39d | 2021-04-20 | 2021-11-23 | 179.12d | 2021-04-20 | 2021-11-23 | 0d |  |  | Banda alimentación de botellas. [200%]; Abridor de pacas. [200%]; Banda de transporte. [200%]; Banda de alimentación a equipo pre lavado. [200%]; Equipo pre lavado rotativo. [200%]; Equipo separador de etiquetas 3 módulos. [200%]; Banda de transporte con detector de metal 1 [200%]; Banda de transporte con detector de metal 2 [200%]; Banda de transporte con detector de metal 3 [200%]; Banda de selección manual [200%]; Banda de alimentación de los molinos [200%]; Molino de corte 1 [200%]; Molino de corte 2 [200%]; Ventiladores de transporte con tubería [200%]; Empacadora de granulo [200%]; Reactor de lavado 1, 2, 3. [200%]; Sistema de recirculación de agua de los molinos [200%]; Tanque de flotación [200%]; Hilos de almacenamiento 1,2,3 [200%]; Empacadora neumática [200%]; Extrusor de doble tornillo [200%]; Cortadora [200%]; Director de Proyecto; Coordinador de compras; Ingeniero de instrumentación y control | 4299h | 1289.7h | 24,231,676,678.6 | 9,010,279,942 | 1,800,000,000 |
| 31 | 1.3.2 | **1.3.2 Nacionalización de Equipos** | 285.52d | 2021-04-20 A | 2022-03-18 |  | 55% | 128.49d | 2021-04-20 | 2022-01-07 | 225.25d | 2021-04-20 | 2022-01-07 | 9.85d |  |  |  | 5208h | 2864.4h | 63,629,906.7 | 20,261,518 | 3,000,000 |
| 32 | 1.3.2.1 | 1.3.2.1 Describir equipos a la agencia de aduanas para nacionalización | 217d | 2021-04-20 A | 2022-03-18 | 30 | 55% | 97.65d | 2021-04-20 | 2022-01-07 | 217d | 2021-04-20 | 2022-01-07 | 9.85d | 0d |  | Computador Portatil [1 x Unid]; Director de Proyecto; Coordinador de compras; Almacenista 1 | 5208h | 2864.4h | 63,629,906.7 | 20,261,518 | 3,000,000 |
| 33 | 1.3.3 | **1.3.3 Recepción y almacenamiento de equipos en planta** | 236.5d | 2022-03-18 | 2022-12-20 |  |  |  | 2022-01-07 | 2022-09-21 | 220.75d | 2022-01-07 | 2022-09-27 | 8.22d |  |  |  | 17686h |  | 308,673,629.36 | 252,134,745 | 43,354,274.36 |
| 34 | 1.3.3.1 | 1.3.3.1 Almacenar y distribuir los equipos. | 262.12d | 2022-03-18 | 2022-12-20 | 32 |  |  | 2022-01-07 | 2022-09-21 | 245.88d | 2022-01-07 | 2022-09-27 | 8.22d |  | finish no earlier than 2022-09-06 | Alquiler de Montacarga [2 x Unid]; Computador Portatil [1 x Unid]; Director de Proyecto; Coordinador de compras; Almacenista 1; Almacenista 2; Auxiliar de montaje 1; Auxiliar de montaje 2; Auxiliar de montaje 3; Auxiliar de montaje 4; Auxiliar de montaje 5; Profesio... | 17686h |  | 308,673,629.36 | 252,134,745 | 43,354,274.36 |
| 35 | 1.4 | **1.4 MONTAJE DE PLANTA** | 194.75d | 2022-02-16 | 2022-09-30 |  |  |  | 2022-02-16 | 2022-09-30 | 194.75d | 2022-02-16 | 2022-09-30 | 76.5d |  |  |  | 194482h |  | 3,514,460,204 | 3,514,460,204 |  |
| 36 | 1.4.1 | **1.4.1 Instalación de equipos** | 194.75d | 2022-02-16 | 2022-09-30 |  |  |  | 2022-02-16 | 2022-09-30 | 194.75d | 2022-02-16 | 2022-09-30 | 76.5d |  |  |  | 110021h |  | 1,972,799,208 | 1,972,799,208 |  |
| 37 | 1.4.1.1 | 1.4.1.1 Realizar montaje de equipos según diseño de planta. | 217d | 2022-02-16 | 2022-09-30 |  |  |  | 2022-02-16 | 2022-09-30 | 217d | 2022-02-16 | 2022-09-30 | 76.5d |  | start no earlier than 2022-02-16 | Alquiler de Montacarga [2 x Unid]; Soldadura [1500 Kg]; Disco de corte [175 x Unid]; Tornillería varia [0.5 x Unid]; Acetileno por 4Kg [6 x Unid]; Oxigeno [5 x Unid]; Cemento por 50 Kg [300 x Unid]; Brocas [25 x Unid]; Endurecedor [50 x Unid]; Silicona [40 x Unid]; Pintura [5 Cuñete]; Anticorrosivo [4 Cuñete]; Equipo de protección contra caidas [7 x Unid]; Elevador de personas [1 x Unid]; Diferenciales [8 x Unid]; Herramienta menor [50%]; Director de Proyecto; Coordinador de montaje; Coordinador de compras; Almacenista 1; Almacenista 2; Mecánico de montaje 1; Mecánico de montaje 2; Mecánico de montaje 3; Mecánico de montaje 4; Mecánico de montaje 5; Mecánico de montaje 6; Mecánico de montaje 7; Mecánico de montaje 8; Mecánico de montaje 9; Mecánico de montaje 10; Auxiliar de montaje 1; Auxiliar de montaje 2; Auxiliar de montaje 3; Auxiliar de montaje 4; Auxiliar de montaje 5; Auxiliar de montaje 6; Auxiliar de montaje 8; Auxiliar de montaje 7; Auxiliar de montaje 9; Auxiliar de montaje 10; Soldador 1; Soldador 2; Soldador 3; Soldador 4; Soldador 5; Supervisor mecánico 1; Supervisor mecánico 2; Tubero 1; Tubero 2; Tubero 3; Tubero 4; Tubero 5; Ingeniero de instrumentación y control; Ingeniero electricista; Electricista 1; Electricista 2; Electricista 3; Electricista 4; Electricista 5; Electricista 6; Electricista 7; Electricista 8; Electricista 9; Electricista 10; Ayudante de electricista 1; Ayudante de electricista 2; Ayudante de electricista 3; Ayudante de electricista 4; Ayudante de electricista 5; Ayudante de electricista 6; Ayudante de electricista 7; Ayudante de electricista 8; Ayudante de electricista 9; Ayudante de electricista 10; Operador de grúa; Ayudante de operador de grúa; Dibujante de ingeniería 1; Dibujante de ingeniería 2; Operador de montacarga 1; Operador de montacarga 2; Operador de montacarga 3; Operador de montacarga 4; Ingeniero de alineación y medición de vibraciones; Ingeniero civil; Oficial; Profesional de Seguridad y Salud en el Trabajo 1; Profesional de Seguridad y Salud en el Trabajo 2; Jefe de mantenimiento | 110021h |  | 1,972,799,208 | 1,972,799,208 |  |
| 38 | 1.4.2 | **1.4.2 Instalación de servicios de planta** | 148.75d | 2022-02-16 | 2022-08-08 |  |  |  | 2022-02-16 | 2022-08-08 | 148.75d | 2022-02-16 | 2022-08-08 | 122.5d |  |  |  | 83069h |  | 1,516,417,813 | 1,516,417,813 |  |
| 39 | 1.4.2.1 | 1.4.2.1 Realizar montaje de servicios de planta según PID | 165d | 2022-02-16 | 2022-08-08 |  |  |  | 2022-02-16 | 2022-08-08 | 165d | 2022-02-16 | 2022-08-08 | 122.5d |  | start no earlier than 2022-02-16 | Alquiler de Montacarga [1 x Unid]; Soldadura [1500 Kg]; Disco de corte [175 x Unid]; Tornillería varia [0.5 x Unid]; Acetileno por 4Kg [6 x Unid]; Oxigeno [5 x Unid]; Cemento por 50 Kg [300 x Unid]; Brocas [25 x Unid]; Endurecedor [50 x Unid]; Silicona [40 x Unid]; Anticorrosivo [4 Cuñete]; Equipo de protección contra caidas [6 x Unid]; Elevador de personas [1 x Unid]; Diferenciales [7 x Unid]; Herramienta menor [50%]; Pintura [2 Cuñete]; Director de Proyecto; Coordinador de montaje; Coordinador de compras; Almacenista 1; Almacenista 2; Mecánico de montaje 1; Mecánico de montaje 2; Mecánico de montaje 3; Mecánico de montaje 4; Mecánico de montaje 5; Mecánico de montaje 6; Mecánico de montaje 7; Mecánico de montaje 8; Mecánico de montaje 9; Mecánico de montaje 10; Auxiliar de montaje 1; Auxiliar de montaje 2; Auxiliar de montaje 3; Auxiliar de montaje 4; Auxiliar de montaje 5; Auxiliar de montaje 6; Auxiliar de montaje 7; Auxiliar de montaje 8; Auxiliar de montaje 9; Auxiliar de montaje 10; Soldador 1; Soldador 2; Soldador 3; Soldador 4; Soldador 5; Supervisor mecánico 1; Supervisor mecánico 2; Tubero 1; Tubero 2; Tubero 3; Tubero 4; Tubero 5; Ingeniero de instrumentación y control; Ingeniero electricista; Electricista 1; Electricista 2; Electricista 3; Electricista 4; Electricista 5; Electricista 6; Electricista 7; Electricista 8; Electricista 9; Electricista 10; Ayudante de electricista 1; Ayudante de electricista 2; Ayudante de electricista 3; Ayudante de electricista 4; Ayudante de electricista 5; Ayudante de electricista 6; Ayudante de electricista 7; Ayudante de electricista 8; Ayudante de electricista 9; Ayudante de electricista 10; Operador de grúa; Ayudante de operador de grúa; Dibujante de ingeniería 1; Dibujante de ingeniería 2; Operador de montacarga 1; Operador de montacarga 2; Operador de montacarga 3; Operador de montacarga 4; Ingeniero de alineación y medición de vibraciones; Ingeniero civil; Oficial; Profesional de Seguridad y Salud en el Trabajo 1; Profesional de Seguridad y Salud en el Trabajo 2; Jefe de mantenimiento | 83069h |  | 1,516,417,813 | 1,516,417,813 |  |
| 40 | 1.4.3 | **1.4.3 Creación de plan de mantenimiento y codificación de repuestos.** | 89.62d | 2022-06-15 | 2022-09-27 |  |  |  | 2022-06-15 | 2022-09-27 | 89.62d | 2022-06-15 | 2022-09-27 | 0d |  |  |  | 1392h |  | 25,243,183 | 25,243,183 |  |
| 41 | 1.4.3.1 | 1.4.3.1 Diseñar plan de mantenimiento según recomendaciones de fabricante. | 87d | 2022-06-15 | 2022-09-27 |  |  |  | 2022-06-15 | 2022-09-27 | 87d | 2022-06-15 | 2022-09-27 | 0d |  | start no earlier than 2022-06-15 | Computador Portatil [1 x Unid]; Supervisor mecánico 1; Jefe de mantenimiento | 1392h |  | 25,243,183 | 25,243,183 |  |
| 42 | 1.5 | **1.5 PRECOMISIONAMIENTO Y COMISIONAMIENTO DE EQUIPOS** | 79.62d | 2022-09-27 | 2022-12-29 |  |  |  | 2022-09-27 | 2022-12-29 | 79.62d | 2022-09-27 | 2022-12-29 | 0d |  |  |  | 9728h |  | 209,245,566 | 209,245,566 |  |
| 43 | 1.5.1 | **1.5.1 Precomisionamiento y verificación de planos PID** | 50d | 2022-09-27 | 2022-11-24 |  |  |  | 2022-09-27 | 2022-11-24 | 50d | 2022-09-27 | 2022-11-24 | 0d |  |  |  | 6016h |  | 127,745,765.5 | 127,745,765.5 |  |
| 44 | 1.5.1.1 | 1.5.1.1 Realizar chequeos y ensayos en condición des energizada. | 33d | 2022-09-27 | 2022-11-04 | 41 |  |  | 2022-09-27 | 2022-11-04 | 33d | 2022-09-27 | 2022-11-04 | 0d |  |  | Computador Portatil [1 x Unid]; Software [1 x Unid]; Servicio internet [1 x Unid]; Celular comunicación [1 x Unid]; Impresora/ploter [1 x Unid]; Papeleria [1 Paquete]; Director de Proyecto; Coordinador de montaje; Mecánico de montaje 1; Supervisor mecánico 1; Ingeniero de instrumentación y control; Ingeniero electricista; Electricista 1; Ayudante de electricista 1; Ayudante de electricista 2; Ayudante de electricista 3; Dibujante de ingeniería 1; Ingeniero de alineación y medición de vibraciones; Ingeniero civil; Profesional de Seguridad y Salud en el Trabajo 1; Jefe de producción; Auxiliar de producción 1 | 4224h |  | 77,770,573 | 77,770,573 |  |
| 45 | 1.5.1.2 | 1.5.1.2 Verificar que las condiciones estén acordes a los planos de ingeniería | 16d | 2022-11-04 | 2022-11-24 | 44 |  |  | 2022-11-04 | 2022-11-24 | 16d | 2022-11-04 | 2022-11-24 | 0d |  |  | Computador Portatil [1 x Unid]; Software [1 x Unid]; Servicio internet [1 x Unid]; Celular comunicación [1 x Unid]; Impresora/ploter [1 x Unid]; Papeleria [1 Paquete]; Director de Proyecto; Coordinador de montaje; Mecánico de montaje 1; Supervisor mecánico 1; Ingeniero de instrumentación y control; Ingeniero electricista; Electricista 1; Auxiliar de producción 1; Ayudante de electricista 1; Dibujante de ingeniería 1; Ingeniero de alineación y medición de vibraciones; Ingeniero civil; Profesional de Seguridad y Salud en el Trabajo 1; Jefe de producción | 1792h |  | 49,975,192.5 | 49,975,192.5 |  |
| 46 | 1.5.2 | **1.5.2 Comisionamiento prueba de equipos con energía y fluidos** | 29.62d | 2022-11-24 | 2022-12-29 |  |  |  | 2022-11-24 | 2022-12-29 | 29.62d | 2022-11-24 | 2022-12-29 | 0d |  |  |  | 3712h |  | 81,499,800.5 | 81,499,800.5 |  |
| 47 | 1.5.2.1 | 1.5.2.1 Realizar chequeos y ensayos en condición energizada y con fluidos del proceso. | 29d | 2022-11-24 | 2022-12-29 | 45 |  |  | 2022-11-24 | 2022-12-29 | 29d | 2022-11-24 | 2022-12-29 | 0d |  |  | Computador Portatil [1 x Unid]; Software [1 x Unid]; Servicio internet [1 x Unid]; Celular comunicación [1 x Unid]; Impresora/ploter [1 x Unid]; Papeleria [1 Paquete]; Director de Proyecto; Coordinador de montaje; Mecánico de montaje 1; Supervisor mecánico 1; Ingeniero de instrumentación y control; Ingeniero electricista; Electricista 1; Ayudante de electricista 1; Ayudante de electricista 2; Ayudante de electricista 3; Dibujante de ingeniería 1; Ingeniero de alineación y medición de vibraciones; Ingeniero civil; Profesional de Seguridad y Salud en el Trabajo 1; Jefe de producción; Auxiliar de producción 1 | 3712h |  | 81,499,800.5 | 81,499,800.5 |  |
| 48 | 1.6 | **1.6 PUESTA EN MARCHA** | 62.75d | 2022-09-28 | 2022-12-09 |  |  |  | 2022-09-28 | 2022-12-09 | 62.75d | 2022-09-28 | 2022-12-09 | 16.5d |  |  |  | 21320h |  | 473,748,846 | 473,748,846 |  |
| 49 | 1.6.1 | **1.6.1 Parametrización de planta** | 29.5d | 2022-09-28 | 2022-11-01 |  |  |  | 2022-09-28 | 2022-11-01 | 29.5d | 2022-09-28 | 2022-11-01 | 49.62d |  |  |  | 3016h |  | 70,920,189 | 70,920,189 |  |
| 50 | 1.6.1.1 | 1.6.1.1 Realizar ajustes de parámetros operativos de diferentes módulos de la planta. | 29d | 2022-09-28 | 2022-11-01 |  |  |  | 2022-09-28 | 2022-11-01 | 29d | 2022-09-28 | 2022-11-01 | 49.62d |  | start no earlier than 2022-09-28 | Computador Portatil [1 x Unid]; Software [1 x Unid]; Servicio internet [1 x Unid]; Celular comunicación [1 x Unid]; Impresora/ploter [1 x Unid]; Papeleria [1 Paquete]; Director de Proyecto; Coordinador de montaje; Mecánico de montaje 1; Ingeniero de instrumentación y control; Ingeniero electricista; Ingeniero de alineación y medición de vibraciones; Jefe de producción; Jefe de mantenimiento; Auxiliar de producción 1; Auxiliar de producción 2; Operarios de producción 1; Operarios de producción 2; Operarios de producción 3 | 3016h |  | 70,920,189 | 70,920,189 |  |

| ID | WBS | Task | Type | Duration | Start | Finish | Predecessors | Complete | Baseline start | Baseline finish | Baseline duration | Baseline 1 start | Baseline 1 finish | Total slack | Free slack | Constraint | Resources | Work | Cost | Baseline cost | Actual cost |
| --- | --- | --- | --- | --- | --- | --- | --- | --- | --- | --- | --- | --- | --- | --- | --- | --- | --- | --- | --- | --- | --- |
| 51 | 1.6.2 | **1.6.2 Capacitación personal operativo** |  | 55.88d | 2022-09-28 | 2022-12-01 |  |  | 2022-09-28 | 2022-12-01 | 55.88d | 2022-09-28 | 2022-12-01 | 23.38d |  |  |  | 5720h | 118,622,813 | 118,622,813 |  |
| 52 | 1.6.2.1 | 1.6.2.1 Capacitar personal operativo. |  | 55d | 2022-09-28 | 2022-12-01 |  |  | 2022-09-28 | 2022-12-01 | 55d | 2022-09-28 | 2022-12-01 | 23.38d |  | start no earlier than 2022-09-28 | Computador Portatil [1 x Unid]; Software [1 x Unid]; Servicio internet [1 x Unid]; Celular comunicación [1 x Unid]; Impresora/ploter [1 x Unid]; Papeleria [1 Paquete]; Director de Proyecto; Coordinador de montaje; Mecánico de montaje 1; Ingeniero de instrumentación y control; Ingeniero electricista; Ingeniero de alineación y medición de vibraciones; Jefe de mantenimiento; Jefe de producción; Auxiliar de producción 1; Auxiliar de producción 2; Operarios de producción 1; Operarios de producción 2; Operarios de producción 3 | 5720h | 118,622,813 | 118,622,813 |  |
| 53 | 1.6.3 | **1.6.3 Parametrización de equipos** |  | 29.5d | 2022-09-28 | 2022-11-01 |  |  | 2022-09-28 | 2022-11-01 | 29.5d | 2022-09-28 | 2022-11-01 | 49.62d |  |  |  | 3016h | 64,472,898 | 64,472,898 |  |
| 54 | 1.6.3.1 | 1.6.3.1 Realizar ajustes de parámetros operativos de equipos de acuerdo a requerimientos de producción. |  | 29d | 2022-09-28 | 2022-11-01 |  |  | 2022-09-28 | 2022-11-01 | 29d | 2022-09-28 | 2022-11-01 | 49.62d |  | start no earlier than 2022-09-28 | Computador Portatil [1 x Unid]; Software [1 x Unid]; Servicio internet [1 x Unid]; Celular comunicación [1 x Unid]; Impresora/ploter [1 x Unid]; Papeleria [1 Paquete]; Director de Proyecto; Coordinador de montaje; Mecánico de montaje 1; Ingeniero de alineación y medición de vibraciones; Ingeniero de instrumentación y control; Ingeniero electricista; Jefe de mantenimiento; Jefe de producción; Auxiliar de producción 1; Auxiliar de producción 2; Operarios de producción 1; Operarios de producción 2; Operarios de producción 3 | 3016h | 64,472,898 | 64,472,898 |  |
| 55 | 1.6.4 | **1.6.4 Arranque de equipos según parámetros operativos.** |  | 62.75d | 2022-09-28 | 2022-12-09 |  |  | 2022-09-28 | 2022-12-09 | 62.75d | 2022-09-28 | 2022-12-09 | 16.5d |  |  |  | 9568h | 219,732,946 | 219,732,946 |  |
| 56 | 1.6.4.1 | 1.6.4.1 Realizar arranque de los equipos y pruebas de funcionamiento integral |  | 61d | 2022-09-28 | 2022-12-09 |  |  | 2022-09-28 | 2022-12-09 | 61d | 2022-09-28 | 2022-12-09 | 16.5d |  | start no earlier than 2022-09-28 | Computador Portatil [1 x Unid]; Software [1 x Unid]; Servicio internet [1 x Unid]; Celular comunicación [1 x Unid]; Impresora/ploter [1 x Unid]; Papeleria [1 Paquete]; Director de Proyecto; Coordinador de montaje; Mecánico de montaje 1; Ingeniero de alineación y medición de vibraciones; Ingeniero de instrumentación y control; Ingeniero electricista; Jefe de mantenimiento; Jefe de producción; Auxiliar de producción 1; Auxiliar de producción 2; Operarios de producción 1; Operarios de producción 2; Operarios de producción 3 | 6344h | 139,063,193 | 139,063,193 |  |
| 57 | 1.6.4.2 | 1.6.4.2 Realizar acta de entrega y arranque de planta al comité de ingeniería |  | 31d | 2022-09-28 | 2022-11-03 |  |  | 2022-09-28 | 2022-11-03 | 31d | 2022-09-28 | 2022-11-03 | 47.88d | 0d | start no earlier than 2022-09-28 | Computador Portatil [1 x Unid]; Software [1 x Unid]; Servicio internet [1 x Unid]; Celular comunicación [1 x Unid]; Impresora/ploter [1 x Unid]; Papeleria [1 Paquete]; Director de Proyecto; Coordinador de montaje; Mecánico de montaje 2; Ingeniero de alineación y medición de vibraciones; Ingeniero de instrumentación y control; Ingeniero electricista; Jefe de mantenimiento; Jefe de producción; Auxiliar de producción 1; Auxiliar de producción 2; Operarios de producción 1; Operarios de producción 2; Operarios de producción 3 | 3224h | 80,669,753 | 80,669,753 |  |
| 58 | 1.7 | **1.7 FINAL** |  | 0d | 2022-11-03 | 2022-11-03 |  |  | 2022-11-03 | 2022-11-03 | 0d | 2022-11-03 | 2022-11-03 | 47.88d |  |  |  |  |  |  |  |
| 59 | 1.7.1 | 1.7.1 Cierre | milestone | 0d | 2022-11-03 | 2022-11-03 | 57 |  | 2022-11-03 | 2022-11-03 | 0d | 2022-11-03 | 2022-11-03 | 47.88d |  |  |  |  |  |  |  |
| 60 | 1.8 | **1.8 RESERVA DE CONTINGENCIA** |  | 1d | 2021-01-04 A | 2021-01-04 A |  | 100% | 2021-01-04 | 2021-01-04 | 1d | 2021-01-04 | 2021-01-04 |  |  |  |  |  | 1,731,446,161 | 1,731,446,161 | 1,731,446,161 |
| 61 | 1.8.1 | 1.8.1 Reserva de Contigencia |  | 1d | 2021-01-04 A | 2021-01-04 A |  | 100% | 2021-01-04 | 2021-01-04 | 1d | 2021-01-04 | 2021-01-04 |  |  |  |  |  | 1,731,446,161 | 1,731,446,161 | 1,731,446,161 |
